# Proyect Simon Bolivar

Schedule from MS Project, 2025-07-01 to 2025-12-27.

## Calendars

- Estándar: Mon-Sun 08:00-12:00, 13:00-17:00.

## Schedule

| ID | WBS | Task | Type | Duration | Start | Finish | Predecessors | Total slack | Free slack | Text2 | Text1 |
| --- | --- | --- | --- | --- | --- | --- | --- | --- | --- | --- | --- |
| 1 | 1 | **VIA SIMON BOLIVAR** |  | 180d | 2025-07-01 | 2025-12-27 |  | 0d |  |  |  |
| 2 | 1.1 | Inicio de obra | milestone | 0d | 2025-07-01 | 2025-07-01 |  | 0d |  |  |  |
| 3 | 1.2 | **OBRAS PRELIMINARES** |  | 60d | 2025-07-01 | 2025-08-29 |  | 0d |  |  |  |
| 4 | 1.2.1 | LETRERO DE OBRA 4.5X3M (inc. estructura metalica, lona con impresión color) |  | 30d | 2025-07-01 | 2025-07-30 | 2SS | 0d |  | 1,00 |  |
| 5 | 1.2.2 | DESBROCE, DESBOSQUE Y LIMPIEZA |  | 30d | 2025-07-01 | 2025-07-30 | 4SS | 0d |  | 5,50 | Ha |
| 6 | 1.2.3 | REUBICACIÓN DE POSTES / H.A. DE ALUMBRADO (no inc. Desvestimiento) |  | 30d | 2025-07-01 | 2025-07-30 | 4SS | 150d |  | 8,00 |  |
| 7 | 1.2.4 | FRESADA DE CARPETA ASFÁLTICA |  | 60d | 2025-07-01 | 2025-08-29 | 4SS | 120d |  | 67.984,00 | m2 |
| 8 | 1.3 | **MOVIMIENTOS DE TIERRA** |  | 90d | 2025-07-01 | 2025-09-28 |  | 0d |  |  |  |
| 9 | 1.3.1 | EXCAVACION SIN CLASIFICACION (empuje = 60 m) (con % relleno compactado) |  | 60d | 2025-07-01 | 2025-08-29 | 5SS | 0d |  | 9.232,50 | m3 |
| 10 | 1.3.2 | DESALOJO MATERIAL DE EXCAVACION (distancia hasta 10 km) |  | 30d | 2025-07-01 | 2025-07-30 | 9SS | 150d |  | 5.092,50 | m3 |
| 11 | 1.3.3 | MATERIAL DE PRESTAMO IMPORTADO |  | 90d | 2025-07-01 | 2025-09-28 | 9SS | 0d |  | 38.931,06 | m3 |
| 12 | 1.3.4 | TRANSPORTE DE MATERIAL DE PRESTAMO IMPORTADO, LONGITUD DE ACARREO DE 65-180 KM |  | 90d | 2025-07-01 | 2025-09-28 | 11SS | 90d |  | 2.530.518,90 | m3-km |
| 13 | 1.3.5 | MATERIAL DE PRESTAMO LOCAL (*) |  | 30d | 2025-07-01 | 2025-07-30 | 9SS | 0d |  | 4.140,00 | m3 |
| 14 | 1.3.6 | MEJORAMIENTO DE LA SUBRASANTE CON SUELO SELECCIONADO |  | 60d | 2025-07-01 | 2025-08-29 | 13SS | 0d |  | 9.372,74 | m3 |
| 15 | 1.3.7 | TRANSPORTE DE MATERIAL DE MEJORAMIENTO, LONGITUD DE ACARREO DE 45-105 KM |  | 60d | 2025-07-01 | 2025-08-29 | 13SS | 120d |  | 609.228,10 | m3-km |
| 16 | 1.4 | **ESTRUCTURA PAVIMENTO** |  | 180d | 2025-07-01 | 2025-12-27 |  | 0d |  |  |  |
| 17 | 1.4.1 | **ESTRUCTURA DE PAVIMENTO (TRAMO 1 Y TRAMO 2: 0+000 HASTA 2+940)** |  | 153d | 2025-07-01 | 2025-11-30 |  | 0d |  |  |  |
| 18 | 1.4.1.1 | Inicio de estructura | milestone | 0d | 2025-07-01 | 2025-07-01 | 11SS, 13SS, 14SS | 0d |  |  |  |
| 19 | 1.4.1.2 | SUB-BASE CLASE 1 |  | 60d | 2025-08-01 | 2025-09-29 | 18SS+31d | 27d | 0d | 7.145,81 | m3 |
| 20 | 1.4.1.3 | TRANSPORTE DE BASE, SUB-BASE Y H. ASFALTICO LONGITUD DE ACARREO DE 30-110 KM |  | 60d | 2025-08-01 | 2025-09-29 | 19SS | 89d |  | 564.518,99 | m3-km |
| 21 | 1.4.1.4 | IMPRIMACION ASFALTICA. |  | 60d | 2025-09-01 | 2025-10-30 | 19SS+31d | 27d | 0d | 29.400,00 | m2 |
| 22 | 1.4.1.5 | RIEGO DE LIGA |  | 60d | 2025-09-02 | 2025-10-31 | 21SS+1d | 27d | 0d | 29.400,00 | m2 |
| 23 | 1.4.1.6 | CAPA DE RODADURA DE HORM. ASF. MEZCLADO EN PLANTA E=5 cm (2") |  | 60d | 2025-10-02 | 2025-11-30 | 22SS+30d | 27d | 0d | 29.400,00 | m2 |
| 24 | 1.4.1.7 | TRANSPORTE DE BASE, SUB-BASE Y H. ASFALTICO LONGITUD DE ACARREO DE 30-110 KM |  | 60d | 2025-10-02 | 2025-11-30 | 23SS | 27d |  | 114.513,00 | m3-km |

| ID | WBS | Task | Type | Duration | Start | Finish | Predecessors | Total slack | Free slack | Text1 | Text2 |
| --- | --- | --- | --- | --- | --- | --- | --- | --- | --- | --- | --- |
| 25 | 1.4.2 | **BASE ESTABILIZADA** |  | 60d | 2025-10-01 | 2025-11-29 |  | 28d |  |  |  |
| 26 | 1.4.2.1 | Tendido y compactación de Base y RAP estabilizado con emulsión asfaltico e=20 cm |  | 60d | 2025-10-01 | 2025-11-29 | 27SS | 28d |  | m2 | 29.400,00 |
| 27 | 1.4.2.2 | BASE CLASE 1 |  | 60d | 2025-10-01 | 2025-11-29 | 18SS+92d | 28d | 0d | m3 | 2.352,00 |
| 28 | 1.4.2.3 | TRANSPORTE DE BASE, SUB-BASE Y H. ASFALTICO LONGITUD DE ACARREO DE 30-110 KM |  | 60d | 2025-10-01 | 2025-11-29 | 27SS | 28d |  | m3-km | 185.808,00 |
| 29 | 1.4.3 | **ESTRUCTURA DE PAVIMENTO (TRAMO 3: 2+940 HASTA 9+172)** |  | 120d | 2025-08-30 | 2025-12-27 |  | 0d |  |  |  |
| 30 | 1.4.3.1 | SUB-BASE CLASE 1 |  | 90d | 2025-08-30 | 2025-11-27 | 18SS+60d | 0d |  | m3 | 13.574,21 |
| 31 | 1.4.3.2 | TRANSPORTE DE BASE, SUB-BASE Y H. ASFALTICO LONGITUD DE ACARREO DE 30-110 KM |  | 90d | 2025-08-30 | 2025-11-27 | 30SS | 30d |  | m3-km | 1.072.362,59 |
| 32 | 1.4.3.3 | BASE CLASE 1 |  | 60d | 2025-09-29 | 2025-11-27 | 30SS+30d | 0d |  | m3 | 9.662,18 |
| 33 | 1.4.3.4 | TRANSPORTE DE BASE, SUB-BASE Y H. ASFALTICO LONGITUD DE ACARREO DE 30-110 KM |  | 60d | 2025-09-29 | 2025-11-27 | 32SS | 30d |  | m3-km | 763.312,22 |
| 34 | 1.4.3.5 | IMPRIMACION ASFALTICA. |  | 60d | 2025-10-29 | 2025-12-27 | 32SS+30d | 0d |  | m2 | 62.252,40 |
| 35 | 1.4.3.6 | RIEGO DE LIGA |  | 60d | 2025-10-29 | 2025-12-27 | 34SS | 0d |  | m2 | 62.252,40 |
| 36 | 1.4.3.7 | CAPA DE RODADURA DE HORM. ASF. MEZCLADO EN PLANTA E=12.5 cm (5") |  | 60d | 2025-10-29 | 2025-12-27 | 35SS | 0d |  | m2 | 43.556,40 |
| 37 | 1.4.3.8 | TRANSPORTE DE BASE, SUB-BASE Y H. ASFALTICO LONGITUD DE ACARREO DE 30-110 KM |  | 60d | 2025-10-29 | 2025-12-27 | 36SS | 0d |  | m3-km | 424.130,45 |
| 38 | 1.4.3.9 | CAPA DE RODADURA DE HORM. ASF. MEZCLADO EN PLANTA E=5 cm (2") |  | 60d | 2025-10-29 | 2025-12-27 | 35SS | 0d |  | m2 | 18.696,00 |
| 39 | 1.4.3.10 | TRANSPORTE DE BASE, SUB-BASE Y H. ASFALTICO LONGITUD DE ACARREO DE 30-110 KM |  | 60d | 2025-10-29 | 2025-12-27 | 38SS | 0d |  | m3-km | 72.820,92 |
| 40 | 1.4.3.11 | Fin de estructura | milestone | 0d | 2025-12-27 | 2025-12-27 | 38, 39, 36 | 0d |  |  |  |
| 41 | 1.5 | **DRENAJE TRANSVERSAL** |  | 123d | 2025-07-01 | 2025-10-31 |  | 57d |  |  |  |
| 42 | 1.5.1 | **OBRAS PRELIMINARES PARA DRENAJE** |  | 60d | 2025-07-01 | 2025-08-29 |  | 87d |  |  |  |
| 43 | 1.5.1.1 | inicio de obras para drenaje | milestone | 0d | 2025-07-01 | 2025-07-01 | 2SS | 90d | 0d |  |  |
| 44 | 1.5.1.2 | LIMPIEZA DE CANALES o DESAZOLVE DE CAUCE (excavadora) (ancho >5m) |  | 30d | 2025-07-31 | 2025-08-29 | 43SS+30d | 120d |  | m3 | 1.152,79 |
| 45 | 1.5.1.3 | REMOCION DE TUBERIA H.A. |  | 30d | 2025-07-31 | 2025-08-29 | 43SS+30d | 120d | 0d |  | 44,20 |
| 46 | 1.5.1.4 | DESALOJO DE ESCOMBROS (distancia hasta 10 km) |  | 30d | 2025-07-31 | 2025-08-29 | 45SS | 120d |  | m3 | 8,33 |
| 47 | 1.5.1.5 | EXCAVACION Y RELLENO PARA ESTRUCTURAS |  | 30d | 2025-07-31 | 2025-08-29 | 2SS+30d | 57d | 0d | m3 | 422,40 |
| 48 | 1.5.2 | **DUCTOS CAJÓN** |  | 63d | 2025-08-30 | 2025-10-31 |  | 57d |  |  |  |
| 49 | 1.5.2.1 | HORMIGON NO ESTRUCTURAL CLASE "E" (f´c=180 kg/cm2) PARA REPLANTILLOS |  | 60d | 2025-08-30 | 2025-10-28 | 47 | 57d | 0d | m3 | 22,98 |
| 50 | 1.5.2.2 | ACERO DE REFUERZO EN BARRAS (f´y=4200 kg/cm2) |  | 60d | 2025-08-31 | 2025-10-29 | 49SS+1d | 57d | 0d | Kg | 23.659,12 |
| 51 | 1.5.2.3 | HORMIGON ESTRUCTURAL CLASE "B" (f´c=240 kg/cm2) (INC. INHIBIDOR DE CORROSION Y ENCOFRADO) |  | 60d | 2025-09-02 | 2025-10-31 | 50SS+2d | 57d |  | m3 | 135,96 |

| ID | WBS | Task | Type | Duration | Start | Finish | Predecessors | Total slack | Free slack | Text1 | Text2 |
| --- | --- | --- | --- | --- | --- | --- | --- | --- | --- | --- | --- |
| 52 | 1.5.3 | **CABEZALES DE DESCARGA PARA DUCTOS CAJÓN** |  | 60d | 2025-07-31 | 2025-09-28 |  | 90d |  |  |  |
| 53 | 1.5.3.1 | RELLENO COMPACTADO (compactador manual) |  | 60d | 2025-07-31 | 2025-09-28 | 43SS+30d | 90d | 0d | m3 | 125,00 |
| 54 | 1.5.3.2 | ENROCADO PARA PROTECCIÓN DE PUENTES Y RIVERAS DE RIOS |  | 60d | 2025-07-31 | 2025-09-28 | 43SS+30d | 90d | 0d | m3 | 115,72 |
| 55 | 1.5.3.3 | TRANSPORTE DE MATERIAL ENROCADO-PIEDRA, LONGITUD DE ACARREO DE 75-180 KM |  | 60d | 2025-07-31 | 2025-09-28 | 54SS | 90d |  | m3-km | 9.141,88 |
| 56 | 1.5.3.4 | LIMPIEZA DE CANALES o DESAZOLVE DE CAUCE (excavadora) (ancho >5m) |  | 60d | 2025-07-31 | 2025-09-28 | 43SS+30d | 90d |  | m3 | 1.305,00 |
| 57 | 1.5.3.5 | GEOTEXTIL 1600NT |  | 60d | 2025-07-31 | 2025-09-28 | 53SS | 90d | 0d | m2 | 69,32 |
| 58 | 1.5.3.6 | HORMIGON NO ESTRUCTURAL CLASE "E" (f´c=180 kg/cm2) PARA REPLANTILLOS |  | 60d | 2025-07-31 | 2025-09-28 | 57SS | 90d | 0d | m3 | 12,42 |
| 59 | 1.5.3.7 | HORMIGON ESTRUCTURAL CLASE "B" (f´c=240 kg/cm2) (INC. INHIBIDOR DE CORROSION Y ENCOFRADO) |  | 60d | 2025-07-31 | 2025-09-28 | 60SS, 61SS | 90d | 0d | m3 | 131,04 |
| 60 | 1.5.3.8 | ACERO DE REFUERZO EN BARRAS (f´y=4200 kg/cm2) |  | 60d | 2025-07-31 | 2025-09-28 | 58SS | 90d | 0d | Kg | 12.167,00 |
| 61 | 1.5.3.9 | ACERO ESTRUCTURAL A36 (inc. Inhibidor de corrosion) |  | 60d | 2025-07-31 | 2025-09-28 | 58SS | 90d | 0d | Kg | 514,00 |
| 62 | 1.5.3.10 | Fin para obras de drenajes | milestone | 0d | 2025-09-28 | 2025-09-28 | 59 | 90d |  |  |  |
| 63 | 1.6 | **INSTALACIONES ELECTRICAS** |  | 180d | 2025-07-01 | 2025-12-27 |  | 0d |  |  |  |
| 64 | 1.6.1 | **MEDIA TENSION** |  | 180d | 2025-07-01 | 2025-12-27 |  | 0d |  |  |  |
| 65 | 1.6.1.1 | Inicio de instalaciones electricas | milestone | 0d | 2025-07-01 | 2025-07-01 |  | 0d |  |  |  |
| 66 | 1.6.1.2 | POSTE HORMIGON ARMADO DE 12 M x 500KG |  | 30d | 2025-11-28 | 2025-12-27 | 67SS | 0d |  |  | 15,00 |
| 67 | 1.6.1.3 | SUMINISTRO Y MONTAJE DE ESTRUCTURAS EN POSTES |  | 30d | 2025-11-28 | 2025-12-27 | 65SS+150d | 0d |  |  | 15,00 |
| 68 | 1.6.1.4 | TENSOR A TIERRA SIMPLE EN MEDIO VOLTAJE |  | 30d | 2025-11-28 | 2025-12-27 | 66SS | 0d |  |  | 3,00 |
| 69 | 1.6.1.5 | TENSOR FAROL SIMPLE |  | 30d | 2025-11-28 | 2025-12-27 | 66SS | 0d |  |  | 1,00 |
| 70 | 1.6.1.6 | RETIRO DE ESTRUCTURAS EXISTENTES |  | 30d | 2025-11-28 | 2025-12-27 | 65SS+150d | 0d |  |  | 15,00 |
| 71 | 1.6.1.7 | REUBICACIÓN DE POSTES / H.A. DE ALUMBRADO (no inc. Desvestimiento) |  | 30d | 2025-11-28 | 2025-12-27 | 65SS+150d | 0d |  |  | 15,00 |
| 72 | 1.6.1.8 | REUBICACION DE LINEA 3Φ |  | 30d | 2025-11-28 | 2025-12-27 | 65SS+150d | 0d |  |  | 1.500,00 |
| 73 | 1.6.1.9 | Fin de instalacion electrica | milestone | 0d | 2025-12-27 | 2025-12-27 | 72 | 0d |  |  |  |
| 74 | 1.7 | **PUENTE SOBRE EL RIO CONGO L= 25m** |  | 180d | 2025-07-01 | 2025-12-27 |  | 0d |  |  |  |
| 75 | 1.7.1 | **OBRAS PRELIMINARES** |  | 90d | 2025-07-01 | 2025-09-28 |  | 0d |  |  |  |
| 76 | 1.7.1.1 | Inicio Puente Sobre el Rio Congo | milestone | 0d | 2025-07-01 | 2025-07-01 |  | 0d |  |  |  |
| 77 | 1.7.1.2 | DEMOLICION DE ESTRUCTURAS DE H.A. EXISTENTES |  | 60d | 2025-07-31 | 2025-09-28 | 76SS+30d | 90d | 0d | m3 | 800,26 |
| 78 | 1.7.1.3 | DESALOJO DE ESCOMBROS (distancia hasta 10 km) |  | 60d | 2025-07-31 | 2025-09-28 | 77SS | 90d | 0d | m3 | 800,26 |
| 79 | 1.7.1.4 | EXCAVACION Y RELLENO PARA ESTRUCTURAS |  | 30d | 2025-07-31 | 2025-08-29 | 80SS | 90d | 0d | m3 | 466,05 |
| 80 | 1.7.1.5 | SONDEOS DE EXPLORACION DE SUELOS (Inc. analisis e informe) |  | 30d | 2025-07-31 | 2025-08-29 | 78SS | 90d | 0d |  | 40,00 |

| ID | WBS | Task | Duration | Start | Finish | Predecessors | Total slack | Free slack | Text2 | Text1 |
| --- | --- | --- | --- | --- | --- | --- | --- | --- | --- | --- |
| 81 | 1.7.2 | **SUBESTRUCTURA** | 30d | 2025-07-31 | 2025-08-29 |  | 120d |  |  |  |
| 82 | 1.7.2.1 | **CIMENTACIÓN PROFUNDA** | 30d | 2025-07-31 | 2025-08-29 |  | 120d |  |  |  |
| 83 | 1.7.2.1.1 | PILOTE PREBARRENADO D = 600 mm fc= 350 kg/cm2 (INC. INHIBIDOR CORROSION) | 30d | 2025-07-31 | 2025-08-29 | 79SS | 120d | 0d | 256,00 |  |
| 84 | 1.7.2.1.2 | PRUEBA DE CARGA DINAMICA DE PILOTES (PDA) | 30d | 2025-07-31 | 2025-08-29 | 83SS | 120d |  | 6,00 |  |
| 85 | 1.7.2.1.3 | PRUEBA DE INTEGRIDAD DE PILOTES (PIT) | 30d | 2025-07-31 | 2025-08-29 | 83SS | 120d |  | 16,00 |  |
| 86 | 1.7.3 | **ESTRIBOS** | 90d | 2025-07-31 | 2025-10-28 |  | 59d |  |  |  |
| 87 | 1.7.3.1 | **PROTECCIÓN HIDRÁULICA Y DRENES** | 60d | 2025-07-31 | 2025-09-28 |  | 90d |  |  |  |
| 88 | 1.7.3.1.1 | GEOTEXTIL 1600NT | 60d | 2025-07-31 | 2025-09-28 | 79SS | 90d | 0d | 51,70 | m2 |
| 89 | 1.7.3.1.2 | PIEDRA TRITURADA (SUB-DREN) | 60d | 2025-07-31 | 2025-09-28 | 88SS | 90d | 0d | 16,85 | m3 |
| 90 | 1.7.3.1.3 | TRANSPORTE DE MATERIALES PÉTREOS* | 60d | 2025-07-31 | 2025-09-28 | 89SS | 90d |  | 1.331,15 | m3-km |
| 91 | 1.7.3.1.4 | TUBERIA PVC PERFORADA 6" (Ø150mm) DREN | 60d | 2025-07-31 | 2025-09-28 | 88SS | 90d |  | 20,00 |  |
| 92 | 1.7.3.1.5 | TUBERIA PVC Ø110mm PARA DRENAJE | 60d | 2025-07-31 | 2025-09-28 | 88SS | 90d |  | 26,40 |  |
| 93 | 1.7.3.2 | **ESTRUCTURA** | 60d | 2025-08-30 | 2025-10-28 |  | 29d |  |  |  |
| 94 | 1.7.3.2.1 | HORMIGON NO ESTRUCTURAL CLASE "E" (f´c=180 kg/cm2) PARA REPLANTILLOS | 60d | 2025-08-30 | 2025-10-28 | 76SS+60d | 29d | 0d | 5,00 | m3 |
| 95 | 1.7.3.2.2 | HORMIGON ESTRUCTURAL PREMEZCLADO CLASE "A" (f´c=280 kg/cm2) (inc. encofrado, inc. aditivos) | 60d | 2025-08-30 | 2025-10-28 | 96SS | 29d | 0d | 91,33 | m3 |
| 96 | 1.7.3.2.3 | ACERO DE REFUERZO EN BARRAS (f´y=4200 kg/cm2) | 60d | 2025-08-30 | 2025-10-28 | 94SS | 29d | 0d | 12.236,70 | Kg |
| 97 | 1.7.4 | **SUPERESTRUCTURA** | 120d | 2025-08-30 | 2025-12-27 |  | 0d |  |  |  |
| 98 | 1.7.4.1 | **VIGAS Y APOYOS** | 60d | 2025-09-29 | 2025-11-27 |  | 29d |  |  |  |
| 99 | 1.7.4.1.1 | Viga California T fc=450 kg/cm2 l=25m | 30d | 2025-09-29 | 2025-10-28 | 95SS+30d | 29d | 0d | 5,00 |  |
| 100 | 1.7.4.1.2 | APOYO CON MORTERO DE ALTA RESISTENCIA fc=350 kg/cm2 | 30d | 2025-10-29 | 2025-11-27 | 99 | 30d | 0d | 0,21 | m3 |
| 101 | 1.7.4.1.3 | APOYO DE NEOPRENO - TIPO STUP (40x40x7 cm) | 30d | 2025-10-29 | 2025-11-27 | 100SS | 30d |  | 10,00 |  |
| 102 | 1.7.4.2 | **VIGAS DIAFRAGMAS** | 90d | 2025-08-30 | 2025-11-27 |  | 29d |  |  |  |
| 103 | 1.7.4.2.1 | HORMIGON ESTRUCTURAL CLASE "A" (f´c=280 kg/cm2) (INC. INHIBIDOR DE CORROSION Y ENCOFRADO) | 60d | 2025-09-29 | 2025-11-27 | 104SS+30d | 29d | 0d | 9,20 | m3 |
| 104 | 1.7.4.2.2 | ACERO DE REFUERZO EN BARRAS (f´y=4200 kg/cm2) | 60d | 2025-08-30 | 2025-10-28 | 99SS-30d | 29d | 0d | 1.015,19 | Kg |

| ID | WBS | Task | Type | Duration | Start | Finish | Predecessors | Total slack | Free slack | Text1 | Text2 |
| --- | --- | --- | --- | --- | --- | --- | --- | --- | --- | --- | --- |
| 105 | 1.7.4.3 | **LOSA DE PUENTE Y JUNTAS** |  | 60d | 2025-09-29 | 2025-11-27 |  | 29d |  |  |  |
| 106 | 1.7.4.3.1 | HORMIGON ESTRUCTURAL PREMEZCLADO CLASE "A" (f´c=280 kg/cm2) (inc. encofrado, inc. aditivos) |  | 60d | 2025-09-29 | 2025-11-27 | 107SS | 29d | 0d | m3 | 86,10 |
| 107 | 1.7.4.3.2 | ACERO DE REFUERZO EN BARRAS (f´y=4200 kg/cm2) |  | 60d | 2025-09-29 | 2025-11-27 | 103SS | 29d | 0d | Kg | 6.608,80 |
| 108 | 1.7.4.3.3 | JUNTA DE DILATACION MODULOS DE (432x54x1830)MM (DESPLAZAMIENTO MEDIO) |  | 60d | 2025-09-29 | 2025-11-27 | 106SS | 30d |  |  | 20,00 |
| 109 | 1.7.4.4 | **BARANDAL DE PROTECCION** |  | 31d | 2025-10-29 | 2025-11-28 |  | 29d |  |  |  |
| 110 | 1.7.4.4.1 | HORMIGON ESTRUCTURAL CLASE "A" (f´c=280 kg/cm2) (INC. INHIBIDOR DE CORROSION Y ENCOFRADO) |  | 30d | 2025-10-30 | 2025-11-28 | 112SS, 113SS, 111SS | 29d |  | m3 | 31,75 |
| 111 | 1.7.4.4.2 | ACERO DE REFUERZO EN BARRAS (f´y=4200 kg/cm2) |  | 30d | 2025-10-30 | 2025-11-28 | 106SS+31d | 29d | 0d | Kg | 1.663,04 |
| 112 | 1.7.4.4.3 | SUMINISTRO, FABRICACION Y MONTAJE DE ELEMENTOS DE ACERO ESTRUCTURAL ASTM A588 o A709-50W INC. TRANSPORTE |  | 30d | 2025-10-30 | 2025-11-28 | 106SS+31d | 29d | 0d | kg | 389,05 |
| 113 | 1.7.4.4.4 | SUMINISTRO, FABRICACION Y MONTAJE DE ELEMENTOS DE ACERO ESTRUCTURAL ASTM A-572 INC. TRANSPORTE |  | 30d | 2025-10-29 | 2025-11-27 | 106SS+30d | 30d | 0d | kg | 743,23 |
| 114 | 1.7.4.4.5 | Pernos de anclaje A193 GR B7 d=16mm |  | 30d | 2025-10-30 | 2025-11-28 | 112SS, 113SS | 29d |  |  | 160,00 |
| 115 | 1.7.4.5 | **DRENAJE LONGITUDINAL** |  | 30d | 2025-10-29 | 2025-11-27 |  | 30d |  |  |  |
| 116 | 1.7.4.5.1 | TUBERIA PVC Ø110mm PARA DRENAJE |  | 30d | 2025-10-29 | 2025-11-27 | 113SS | 30d |  |  | 9,00 |
| 117 | 1.7.4.5.2 | TUBERIA PVC Ø160mm DRENAJE |  | 30d | 2025-10-29 | 2025-11-27 | 113SS | 30d |  |  | 50,00 |
| 118 | 1.7.4.6 | **LOSA DE APROXIMACIÓN** |  | 30d | 2025-10-29 | 2025-11-27 |  | 0d |  |  |  |
| 119 | 1.7.4.6.1 | SUB-BASE CLASE 3 |  | 30d | 2025-10-29 | 2025-11-27 | 76SS+120d | 0d |  | m3 | 72,80 |
| 120 | 1.7.4.6.2 | TRANSPORTE DE BASE, SUB-BASE Y H. ASFALTICO LONGITUD DE ACARREO DE 30-110 KM |  | 30d | 2025-10-29 | 2025-11-27 | 119SS | 30d |  | m3-km | 5.751,20 |
| 121 | 1.7.4.6.3 | HORMIGON NO ESTRUCTURAL CLASE "E" (f´c=180 kg/cm2) PARA REPLANTILLOS |  | 30d | 2025-10-29 | 2025-11-27 | 119SS | 30d | 0d | m3 | 6,70 |
| 122 | 1.7.4.6.4 | HORMIGON ESTRUCTURAL CLASE "A" (f´c=280 kg/cm2) (INC. INHIBIDOR DE CORROSION Y ENCOFRADO) |  | 30d | 2025-10-29 | 2025-11-27 | 123SS | 30d |  | m3 | 14,40 |
| 123 | 1.7.4.6.5 | ACERO DE REFUERZO EN BARRAS (f´y=4200 kg/cm2) |  | 30d | 2025-10-29 | 2025-11-27 | 121SS | 30d | 0d | Kg | 1.920,00 |
| 124 | 1.7.4.7 | **CAPA DE RODADURA** |  | 30d | 2025-11-28 | 2025-12-27 |  | 0d |  |  |  |
| 125 | 1.7.4.7.1 | RIEGO DE LIGA |  | 30d | 2025-11-28 | 2025-12-27 | 119SS+30d | 0d |  | m2 | 200,00 |
| 126 | 1.7.4.7.2 | CAPA DE RODADURA DE HORM. ASF. MEZCLADO EN PLANTA E=5 cm (2") |  | 30d | 2025-11-28 | 2025-12-27 | 125SS | 0d |  | m2 | 200,00 |
| 127 | 1.7.4.7.3 | TRANSPORTE DE BASE, SUB-BASE Y H. ASFALTICO LONGITUD DE ACARREO DE 30-110 KM |  | 30d | 2025-11-28 | 2025-12-27 | 126SS | 0d |  | m3-km | 779,00 |
| 128 | 1.7.4.7.4 | Fin Puente Sobre el Rio Congo | milestone | 0d | 2025-12-27 | 2025-12-27 | 126 | 0d |  |  |  |

| ID | WBS | Task | Type | Duration | Start | Finish | Predecessors | Total slack | Text2 | Text1 |
| --- | --- | --- | --- | --- | --- | --- | --- | --- | --- | --- |
| 129 | 1.7.5 | **ILUMINACION** |  | 30d | 2025-11-28 | 2025-12-27 |  | 0d |  |  |
| 130 | 1.7.5.1 | LUMINARIA LED SOLAR ALL IN ONE 5700K 80W/18V (FL >11500LM) |  | 30d | 2025-11-28 | 2025-12-27 | 131SS | 0d | 3,00 |  |
| 131 | 1.7.5.2 | POSTE CONICO 9MTS BASE 30X30CM C/4 PERNOS DE ANCLAJE |  | 30d | 2025-11-28 | 2025-12-27 | 76SS+150d | 0d | 3,00 |  |
| 132 | 1.7.6 | **PROTECCIONES** |  | 180d | 2025-07-01 | 2025-12-27 |  | 0d |  |  |
| 133 | 1.7.6.1 | **PROTECCIÓN DE RIVERAS** |  | 180d | 2025-07-01 | 2025-12-27 |  | 0d |  |  |
| 134 | 1.7.6.1.1 | Inicio proteccion de riveras | milestone | 0d | 2025-07-01 | 2025-07-01 |  | 0d |  |  |
| 135 | 1.7.6.1.2 | EXCAVACION Y DESALOJO (excavadora, volqueta ) |  | 60d | 2025-10-29 | 2025-12-27 | 134SS+120d | 0d | 18.524,20 | m3 |
| 136 | 1.7.6.1.3 | RELLENO COMPACTADO CON COMP. MANUAL (material del sitio) |  | 60d | 2025-10-29 | 2025-12-27 | 135SS | 0d | 9.375,00 | m3 |
| 137 | 1.7.6.1.4 | GEOMALLA TRIAXIAL |  | 60d | 2025-10-29 | 2025-12-27 | 136SS | 0d | 15.687,84 | m2 |
| 138 | 1.7.6.1.5 | GEOTEXTIL 1600NT |  | 60d | 2025-10-29 | 2025-12-27 | 137SS | 0d | 15.687,84 | m2 |
| 139 | 1.7.6.1.6 | Recubrimiento con mortero de alta resistencia |  | 30d | 2025-11-28 | 2025-12-27 | 140SS+30d | 0d | 826,00 | m2 |
| 140 | 1.7.6.1.7 | ENROCADO PARA PROTECCIÓN DE PUENTES Y RIVERAS DE RIOS |  | 60d | 2025-10-29 | 2025-12-27 | 138SS | 0d | 11.684,40 | m3 |
| 141 | 1.7.6.1.8 | TRANSPORTE DE MATERIAL ENROCADO-PIEDRA, LONGITUD DE ACARREO DE 75-180 KM |  | 60d | 2025-10-29 | 2025-12-27 | 140SS | 0d | 923.067,60 | m3-km |
| 142 | 1.7.6.1.9 | Fin de proteccion de riveras | milestone | 0d | 2025-12-27 | 2025-12-27 | 139 | 0d |  |  |
| 143 | 1.8 | **PARADERO BUS** |  | 180d | 2025-07-01 | 2025-12-27 |  | 0d |  |  |
| 144 | 1.8.1 | Inicio paradero bus | milestone | 0d | 2025-07-01 | 2025-07-01 |  | 0d |  |  |
| 145 | 1.8.2 | RELLENO COMPACTADO (compactador manual) |  | 30d | 2025-11-28 | 2025-12-27 | 144SS+150d | 0d | 12,28 | m3 |
| 146 | 1.8.3 | HORMIGON NO ESTRUCTURAL CLASE "E" (f´c=180 kg/cm2) PARA REPLANTILLOS |  | 30d | 2025-11-28 | 2025-12-27 | 145SS | 0d | 1,55 | m3 |
| 147 | 1.8.4 | HORMIGON ESTRUCTURAL CLASE "A" (f´c=280 kg/cm2) (INC. INHIBIDOR DE CORROSION Y ENCOFRADO) |  | 30d | 2025-11-28 | 2025-12-27 | 148SS | 0d | 0,98 | m3 |
| 148 | 1.8.5 | ACERO DE REFUERZO EN BARRAS (f´y=4200 kg/cm2) |  | 30d | 2025-11-28 | 2025-12-27 | 146SS | 0d | 41,42 | Kg |
| 149 | 1.8.6 | CUBIERTA DE POLICARBONATO SIN ESTRUCTURA |  | 30d | 2025-11-28 | 2025-12-27 | 150SS | 0d | 8,40 | m2 |
| 150 | 1.8.7 | ACERO ESTRUCTURAL A36 (inc. Inhibidor de corrosion) |  | 30d | 2025-11-28 | 2025-12-27 | 147SS | 0d | 154,28 | Kg |
| 151 | 1.8.8 | Fin paradero bus | milestone | 0d | 2025-12-27 | 2025-12-27 | 149 | 0d |  |  |
| 152 | 1.9 | **SEÑALIZACION** |  | 180d | 2025-07-01 | 2025-12-27 |  | 0d |  |  |
| 153 | 1.9.1 | **SEÑALIZACION HORIZONTAL** |  | 180d | 2025-07-01 | 2025-12-27 |  | 0d |  |  |
| 154 | 1.9.1.1 | Inicio de señalectica | milestone | 0d | 2025-07-01 | 2025-07-01 |  | 0d |  |  |
| 155 | 1.9.1.2 | SEÑALIZACION HORIZONTAL CONTINUA CON PINTURA TERMOPLASTICA E=2,3 MM EN SECO (VIA 15 CM AMARILLA O BLANCA/microesferas) |  | 30d | 2025-11-28 | 2025-12-27 | 154SS+150d | 0d | 11.805,64 |  |
| 156 | 1.9.1.3 | SEÑALIZACION HORIZONTAL SEGMENTADA CON PINTURA TERMOPLASTICA E=2,3 MM EN SECO (VIA 15 CM AMARILLA O BLANCA/microesferas) |  | 30d | 2025-11-28 | 2025-12-27 | 154SS+150d | 0d | 7.855,18 |  |
| 157 | 1.9.1.4 | MARCAS DE PAVIMENTO C/PINTURA TERMOPLÁSTICA E=2.3MM (SECO) "PASOS CEBRA, FLECHAS, LEYENDAS" |  | 30d | 2025-11-28 | 2025-12-27 | 154SS+150d | 0d | 955,45 | m2 |
| 158 | 1.9.1.5 | MARCADORES DE PAVIMENTO RETROREFLEJANTES (TACHAS) (bidireccionales) |  | 30d | 2025-11-28 | 2025-12-27 | 154SS+150d | 0d | 2.293,00 |  |

| ID | WBS | Task | Duration | Start | Finish | Predecessors | Total slack | Text2 | Text1 |
| --- | --- | --- | --- | --- | --- | --- | --- | --- | --- |
| 159 | 1.9.2 | **SEÑALIZACION VERTICAL** | 90d | 2025-09-29 | 2025-12-27 |  | 0d |  |  |
| 160 | 1.9.2.1 | Señales al lado de la carretera (750x900 + 750x900) | 90d | 2025-09-29 | 2025-12-27 | 154SS+90d | 0d | 48,00 |  |
| 161 | 1.9.2.2 | Señales al lado de la carretera (750x750) | 90d | 2025-09-29 | 2025-12-27 | 154SS+90d | 0d | 89,00 |  |
| 162 | 1.9.2.3 | Señales al lado de la carretera (750x750 + 900x300) | 30d | 2025-11-28 | 2025-12-27 | 154SS+150d | 0d | 2,00 |  |
| 163 | 1.9.2.4 | SEÑALES AL LADO DE LA CARRETERA (1298x420) | 30d | 2025-11-28 | 2025-12-27 | 154SS+150d | 0d | 12,00 |  |
| 164 | 1.9.2.5 | Señales al lado de la carretera (1200x900) | 30d | 2025-11-28 | 2025-12-27 | 154SS+150d | 0d | 12,00 |  |
| 165 | 1.9.2.6 | Señales al lado de la carretera (1200x600) | 30d | 2025-11-28 | 2025-12-27 | 154SS+150d | 0d | 4,00 |  |
| 166 | 1.9.2.7 | Señales al lado de la carretera (600x600) | 60d | 2025-10-29 | 2025-12-27 | 154SS+120d | 0d | 50,00 |  |
| 167 | 1.9.2.8 | Señales al lado de la carretera (750x600) | 30d | 2025-11-28 | 2025-12-27 | 154SS+150d | 0d | 4,00 |  |
| 168 | 1.9.2.9 | Señales al lado de la carretera (450x600+450x600) | 30d | 2025-11-28 | 2025-12-27 | 154SS+150d | 0d | 9,00 |  |
| 169 | 1.9.2.10 | GUARDA CAMINO TIPO VIGA METALICA (doble) | 60d | 2025-10-29 | 2025-12-27 | 154SS+120d | 0d | 343,45 |  |
| 170 | 1.9.3 | **SEÑALIZACION TEMPORAL** | 30d | 2025-07-01 | 2025-07-30 |  | 150d |  |  |
| 171 | 1.9.3.1 | SUMINISTRO E INSTALACION DE TUBO METALICO CUADRADO DE 2" | 30d | 2025-07-01 | 2025-07-30 | 2SS | 150d | 92,00 |  |
| 172 | 1.9.3.2 | CINTA PLASTICA DE PELIGRO (1 LINEA) | 30d | 2025-07-01 | 2025-07-30 | 2SS | 150d | 3.057,00 |  |
| 173 | 1.9.3.3 | BARRICADA DE MADERA (0,6X1.1)M C/2TABLONES C/ CINTA REFLECTIVA | 30d | 2025-07-01 | 2025-07-30 | 2SS | 150d | 9,00 |  |
| 174 | 1.9.3.4 | BARRICADA DE MADERA (1.20 X 1.50)M C/3 TABL.C/CINTA REFLECTIVA | 30d | 2025-07-01 | 2025-07-30 | 2SS | 150d | 9,00 |  |
| 175 | 1.9.3.5 | BARRICADA DE MADERA (2.40 X 1.50)M C/3 TABL.C/CINTA REFLECTIVA | 30d | 2025-07-01 | 2025-07-30 | 2SS | 150d | 9,00 |  |
| 176 | 1.9.3.6 | TANQUE PROTECTOR VIAL DE POLIETILENO H=1,02M D=0,62M (INC. BASE) | 30d | 2025-07-01 | 2025-07-30 | 2SS | 150d | 18,00 |  |
| 177 | 1.9.3.7 | PARANTE VIAL DE POLIETILENO DE H=1,41M; D=0,74M (INC.BASE) | 30d | 2025-07-01 | 2025-07-30 | 2SS | 150d | 46,00 |  |
| 178 | 1.9.3.8 | CONOS REFLECTIVOS (H=90 CM). | 30d | 2025-07-01 | 2025-07-30 | 2SS | 150d | 40,00 |  |
| 179 | 1.9.3.9 | DISPOSITIVO SEÑAL LUMINOSA DE PREVENCION ( H=0,3,A=0,2)M CON BATERIA DE 6 VOLTIOS | 30d | 2025-07-01 | 2025-07-30 | 2SS | 150d | 9,00 |  |
| 180 | 1.9.3.10 | CONSTRUCCION E INSTALACION DE LETRERO METALICO REFLECTIVO SEÑALIZACION | 30d | 2025-07-01 | 2025-07-30 | 2SS | 150d | 6,00 | m2 |
| 181 | 1.9.3.11 | CONOS REFLECTIVOS (H=70 CM) | 30d | 2025-07-01 | 2025-07-30 | 2SS | 150d | 92,00 |  |
| 182 | 1.9.3.12 | MALLA PLASTICA DE SEGURIDAD (COLOR) | 30d | 2025-07-01 | 2025-07-30 | 2SS | 150d | 3.600,00 | m2 |

| ID | WBS | Task | Type | Duration | Start | Finish | Predecessors | Total slack | Text1 | Text2 |
| --- | --- | --- | --- | --- | --- | --- | --- | --- | --- | --- |
| 183 | 1.10 | **AMBIENTALES** |  | 180d | 2025-07-01 | 2025-12-27 |  | 0d |  |  |
| 184 | 1.10.1 | Agua para control de polvo |  | 150d | 2025-07-01 | 2025-11-27 | 2SS | 30d | m3 | 40.825,39 |
| 185 | 1.10.2 | BATERIA SANITARIA PORTATIL ( unidad x mes) |  | 150d | 2025-07-01 | 2025-11-27 | 2SS | 30d |  | 30,00 |
| 186 | 1.10.3 | SEÑALES PREVENTIVAS TEMPORALES |  | 180d | 2025-07-01 | 2025-12-27 | 2SS | 0d |  | 18,00 |
| 187 | 1.10.4 | TANQUE DE 55 GALONES (PARA BASURA) |  | 30d | 2025-07-01 | 2025-07-30 | 2SS | 150d |  | 9,00 |
| 188 | 1.10.5 | ESCOMBRERAS (DISPOSICIÓN FINAL Y TRATAMIENTO PAISAJISTICO DE ZONAS DE DEPOSITO) |  | 90d | 2025-07-01 | 2025-12-27 | 2SS | 0d | m3 | 5.901,00 |
| 189 | 1.10.6 | Reunion informativa con la comunidad |  | 60d | 2025-10-29 | 2025-12-27 | 2SS+120d | 0d |  | 6,00 |
| 190 | 1.10.7 | MONITOREO DE RUIDO |  | 90d | 2025-07-01 | 2025-12-27 | 2SS | 0d |  | 6,00 |
| 191 | 1.10.8 | MONITOREO DE CALIDAD DE AIRE AMBIENTE |  | 180d | 2025-07-01 | 2025-12-27 | 2SS | 0d |  | 6,00 |
| 192 | 1.10.9 | Monitoreo de Calidad de aire (material particulado PM2.5) |  | 180d | 2025-07-01 | 2025-12-27 | 2SS | 0d |  | 6,00 |
| 193 | 1.10.10 | Monitoreo de Calidad de aire (material particulado PM10) |  | 180d | 2025-07-01 | 2025-12-27 | 2SS | 0d |  | 6,00 |
| 194 | 1.10.11 | ANALISIS QUIMICO DE CALIDAD DE AGUA |  | 90d | 2025-07-01 | 2025-12-27 | 2SS | 0d |  | 6,00 |
| 195 | 2 | Fin de obra | milestone | 0d | 2025-12-27 | 2025-12-27 | 153, 159 | 0d |  |  |
